# Projet_laser_GE4

Schedule from GanttProject, 2024-02-08 to 2025-01-17.

## Calendars

- Project calendar: Mon-Tue off; Wed working; Thu off; Fri working; Sat-Sun off. Exceptions (off unless hours are given): 2024-02-26 to 2024-03-01, 2024-03-23 to 2024-09-12, 2024-10-28 to 2024-11-01.

## Schedule

| ID | Task | Type | Duration | Start | Finish | Predecessors | Complete | Constraint |
| --- | --- | --- | --- | --- | --- | --- | --- | --- |
| 1 | Lire l'ensemble des livrables et compréhension de la carte |  | 12d | 2024-02-08 | 2024-09-13 |  | 100% |  |
| 2 | Mettre ces scripts sous forme de fonctions |  | 1d | 2024-02-23 | 2024-02-23 | 3 | 100% |  |
| 3 | Créer et simuler des systèmes d'ordre 1 à 3 |  | 5d | 2024-02-08 | 2024-02-23 |  | 100% |  |
| 4 | Mettre toutes les méthodes d'identification sous forme de fonctions |  | 1d | 2024-11-13 | 2024-11-13 | 5, 6, 7 | 100% |  |
| 5 | Simuler l'identification par la fonction ARMAX |  | 5d | 2024-10-18 | 2024-11-08 |  | 100% |  |
| 6 | Simuler l'identification par la méthode des Variables Instrumentales |  | 4d | 2024-03-06 | 2024-03-15 | 43 | 100% |  |
| 7 | Simuler l'identification par la méthode de la pseudo-inverse |  | 5d | 2024-03-06 | 2024-03-20 | 43 | 100% |  |
| 8 | Trouver les paramètres d'identification optimaux |  | 5d | 2024-03-20 | 2024-09-20 | 6, 30 | 100% |  |
| 9 | Réaliser une série d'acquisition avec les paramètres optimaux |  | 6d | 2024-03-22 | 2024-09-27 |  | 100% |  |
| 10 | Convertir les coefficients discrets en continus |  | 3d | 2024-10-02 | 2024-10-09 |  | 100% |  |
| 11 | Réaliser l'identification du système selon les 3 méthodes |  | 1d | 2024-11-13 | 2024-11-13 | 5, 6, 7, 9 | 100% |  |
| 12 | Réaliser l'identification dans des conditions de pression différentes |  | 1d | 2024-11-22 | 2024-11-22 |  |  |  |
| 13 | cloche à vide trouvée | milestone | 0d | 2024-10-25 | 2024-10-25 |  | 100% |  |
| 14 | Calculer la fonction de transfert cible qui valide le cahier des charges |  | 1d | 2024-03-22 | 2024-03-22 |  | 100% |  |
| 15 | Calculer les coefficients d'un correcteur RST avec intégrateur |  | 2d | 2024-09-13 | 2024-09-18 | 14 | 100% |  |
| 16 | Mettre le calcul des coefficients RST sous forme d'une fonction |  | 1d | 2024-10-25 | 2024-10-25 | 17, 18 | 100% |  |
| 17 | Calculer les coefficients d'un correcteur RST sans intégrateur |  | 1d | 2024-10-18 | 2024-10-18 |  | 100% |  |
| 18 | Vérification de la stabilitié des différents blocs des deux correcteurs |  | 1d | 2024-10-23 | 2024-10-23 | 15, 17 | 100% |  |
| 19 | Créer un Script permettant d'envoyer les coefficients RST dans le VHDL |  | 2d | 2024-10-09 | 2024-10-11 |  | 100% |  |
| 20 | Créer un script permettant de convertir des nombres flottants en valeur décimale de leur code hexadecimal |  | 3d | 2024-10-18 | 2024-10-25 |  | 100% |  |
| 21 | Refaire le script calculant les sorties théoriques du bloc RST sur Scilab |  | 2d | 2024-10-23 | 2024-10-25 | 22 | 100% |  |
| 22 | Vérification des codes utilisés l'an dernier |  | 2d | 2024-10-16 | 2024-10-18 | 19 | 100% |  |
| 23 | Modifier le script de test du RST pour imposer la valeur de la sortie Y |  | 4d | 2024-11-06 | 2024-11-15 | 21 | 100% |  |
| 24 | Tester les blocs R, S et T incluts dans le VHDL séparément |  | 4d | 2024-11-20 | 2024-11-29 | 23 | 100% |  |
| 25 | Tester l'intégration de l'ensemble pour des valeurs de Y imposées |  | 1d | 2024-12-04 | 2024-12-04 | 24 | 100% |  |
| 26 | Tester les paramètres calculés du RST en conditions réelles pour s'assurer de ne pas avoir de dépacement de valeurs |  | 2d | 2024-12-06 | 2024-12-11 | 25 | 100% |  |
| 27 | Installer l'ensemble des logiciels/drivers nécessaires au fonctionnement de la carte |  | 2d | 2024-02-14 | 2024-02-16 |  | 100% |  |
| 28 | Vérifier la communication via l'USB Blaster pour compiler le programme |  | 1d | 2024-02-21 | 2024-02-21 | 27 | 100% |  |
| 29 | Vérifier la communication via le port série |  | 2d | 2024-02-23 | 2024-03-06 | 28 | 100% |  |
| 30 | Utiliser les scripts de l'année précédente pour communiquer avec la carte |  | 1d | 2024-03-08 | 2024-03-08 | 29 | 100% |  |
| 31 | Corriger le script d'acquisition des données du galvanomètre |  | 2d | 2024-10-04 | 2024-10-09 |  | 100% |  |
| 32 | Corriger le déclenchement du galvanomètre Y lors d'une identification du galvanomètre X |  | 1d | 2024-12-13 | 2024-12-13 | 26 |  | start no earlier than 2024-10-04 |
| 33 | Faire un Script Scilab pour réaliser l'identification des deux voies, Calculer les coefficients RST, les fournir au VHDL et afficher la matrice de 25 points |  | 4d | 2024-12-13 | 2024-12-25 | 26 |  |  |
| 34 | Mettre en place un test de validation du cahier des charges pour l'affichage de la matrice. |  | 1d | 2024-10-16 | 2024-10-16 |  | 100% |  |
| 35 | Fin prévue du Projet | milestone | 0d | 2025-01-17 | 2025-01-17 | 41, 42 |  |  |
| 36 | Suivre le tutoriel de fonctionnement de la carte et noter toutes les améliorations à ajouter |  | 2d | 2024-11-15 | 2024-11-20 |  | 100% |  |
| 37 | Revue d'avancement n°2 | milestone | 0d | 2024-12-06 | 2024-12-06 |  |  |  |
| 38 | Revue de lancement | milestone | 0d | 2024-10-25 | 2024-10-25 |  | 100% |  |
| 39 | Revue d'avancement n°1 | milestone | 0d | 2024-11-22 | 2024-11-22 |  | 100% |  |
| 40 | Créer l'ensemble des blocs du RST nécessaires séparément |  | 3d | 2024-11-15 | 2024-11-22 |  | 100% |  |
| 41 | Fournir l'ensemble des codes utilisés commentés |  | 4d | 2024-12-27 | 2025-01-08 | 33, 34 | 100% |  |
| 42 | Remettre au propre toutes les notes d'applications |  | 24d | 2024-10-18 | 2025-01-15 |  | 100% |  |
| 43 | Tests des scripts d'identification SBPA de l'année précédente |  | 1d | 2024-02-23 | 2024-02-23 |  | 100% |  |
| 44 | Assembler les blocs pour créer le RST complet |  | 1d | 2024-11-27 | 2024-11-27 | 40 | 100% |  |
| 45 | Revue de fin de projet | milestone | 0d | 2024-12-20 | 2024-12-20 |  |  |  |
| 46 | Recréer la logique de commande du RST |  | 3d | 2024-11-15 | 2024-11-22 |  | 100% |  |
| 47 | Debugger le RST déjà existant |  | 2d | 2024-11-13 | 2024-11-15 |  | 100% |  |
